# LRAUV 08 WBS 2~609

Schedule from MS Project, 2011-01-17 to 2011-12-15, 9 hours a day.
MBARI

## Calendars

- Standard: Mon-Fri 08:00-12:00, 13:00-17:00; Sat-Sun off.

## Resources

| Resource |
| --- |
| Alana |
| Bill |
| Bob |
| Brian |
| Dale |
| Larry |

## Schedule

| ID | WBS | Task | Type | Duration | Start | Finish | Predecessors | Total slack | Free slack | Constraint | Work |
| --- | --- | --- | --- | --- | --- | --- | --- | --- | --- | --- | --- |
| 1 | 1 | Requirements Freeze | milestone | 0d | 2011-03-31 | 2011-03-31 |  | 165.33d |  | start no earlier than 2011-03-31 |  |
| 2 | 2 | PDR | milestone | 0d | 2011-12-15 | 2011-12-15 |  | 0.89d |  | start no earlier than 2011-12-15 |  |
| 3 | 3 | **Proof of Concept Tests** |  | 212.44d | 2011-01-17 | 2011-12-15 |  | 0d |  | start no earlier than 2011-01-03 | 2550h |
| 4 | 1.2 | **Sensor Test Bed** |  | 62d | 2011-01-24 | 2011-04-29 |  | 146d |  |  | 500h |
| 5 | 3.1.1 | Sensor Selection |  | 12d | 2011-01-24 | 2011-02-10 |  | 146d | 0d | start no earlier than 2011-01-24 | 100h |
| 6 | 1.1.2 | Implementation |  | 25d | 2011-02-10 | 2011-03-22 | 5 | 146d | 0d |  | 200h |
| 7 | 3.1.3 | Analysis |  | 25d | 2011-03-22 | 2011-04-29 | 6 | 146d |  |  | 200h |
| 8 | 1.1 | **Modem Sea Trial** |  | 48d | 2011-01-17 | 2011-03-31 |  | 164.44d |  |  | 490h |
| 9 | 3.2.1 | Prep |  | 30d | 2011-01-17 | 2011-03-03 |  | 164.44d | 0d | start no earlier than 2011-01-17 | 250h |
| 10 | 1.1.2 | Implementation |  | 8d | 2011-03-03 | 2011-03-16 | 9 | 164.44d | 0d |  | 120h |
| 11 | 3.2.3 | Analysis |  | 10d | 2011-03-16 | 2011-03-31 | 10 | 164.44d |  |  | 120h |
| 12 | 3.3 | **Prototype BED** |  | 175.11d | 2011-03-09 | 2011-12-09 |  | 0d |  |  | 1380h |
| 13 | 3.3.1 | Finalize requirements and test plan |  | 15d | 2011-03-09 | 2011-03-31 |  | 0d |  | must finish on 2011-03-31 | 180h |
| 14 | 3.3.2 | Mechanical |  | 100d | 2011-05-02 | 2011-10-05 | 13 | 45.78d |  | start no earlier than 2011-05-02 | 420h |
| 15 | 3.3.3 | Electrical |  | 90d | 2011-06-01 | 2011-10-20 | 13 | 36.22d |  | start no earlier than 2011-06-01 | 240h |
| 16 | 3.3.4 | Software |  | 119d | 2011-04-18 | 2011-10-20 | 13 | 35.67d |  | start no earlier than 2011-04-18 | 300h |
| 17 | 3.3.5 | Predeployment/Deployment |  | 25d | 2011-11-01 | 2011-12-09 | 13 | 4.33d |  | start no earlier than 2011-11-01 | 240h |
| 18 | 3.4 | PDR prep |  | 8d | 2011-12-05 | 2011-12-15 |  | 0d |  | must finish on 2011-12-15 | 180h |
